# Run 2C Upgrade Plan

Schedule from MS Project, 2019-10-25 to 2019-12-05.

## Calendars

- Standard: Mon-Fri 08:00-12:00, 13:00-17:00; Sat-Sun off.

## Schedule

| ID | WBS | Task | Duration | Start | Finish | Predecessors | Total slack | Free slack | Constraint |
| --- | --- | --- | --- | --- | --- | --- | --- | --- | --- |
| 2 | 1 | **Condenser Upgrade** | 22d | 2019-10-25 | 2019-11-25 |  | 8d |  |  |
| 3 | 1.1 | **Installation of the return liquid filter (Sintered Metal Rod and Mole Sieve)** | 21d | 2019-10-25 | 2019-11-22 |  | 9d |  |  |
| 4 | 1.1.1 | Document for Mole Sieve operation (Electrical and Temperature) | 5d | 2019-11-13 | 2019-11-19 |  | 11d | 0d | start no earlier than 2019-11-13 |
| 5 | 1.1.2 | Purchase of Sintered Metal Rod (20 micron) | 15d | 2019-10-25 | 2019-11-14 |  | 15d |  | finish no earlier than 2019-11-14 |
| 6 | 1.1.3 | Install Tee on the cryostat | 1d | 2019-11-19 | 2019-11-19 |  | 12d |  | start no earlier than 2019-11-19 |
| 7 | 1.1.4 | Installation of Mole Shiv and Sintered Metal Rod | 1d | 2019-11-20 | 2019-11-20 | 4 | 11d |  |  |
| 8 | 1.1.5 | Mole Sieve heater, power and its control | 8d | 2019-11-13 | 2019-11-22 |  | 9d |  | start no earlier than 2019-11-13 |
| 9 | 1.2 | **Insert of snorkel tube in the condenser through a cross.** | 9d | 2019-11-13 | 2019-11-25 |  | 8d |  |  |
| 10 | 1.2.1 | Purchase snorkel Tube (3/8" ID and 1/2" OD) | 6d | 2019-11-13 | 2019-11-20 |  | 11d |  | start no earlier than 2019-11-13 |
| 11 | 1.2.2 | Mockup of the Tube instering in the condenser | 7d | 2019-11-13 | 2019-11-21 |  | 10d |  | start no earlier than 2019-11-13 |
| 12 | 1.2.3 | Write an HA to insert snorkel Tube from condenser to cryostat | 8d | 2019-11-13 | 2019-11-22 |  | 9d |  | start no earlier than 2019-11-13 |
| 13 | 1.2.4 | Insert fishtape/snorkel tube from condenser to cryostat/Cryostat to Condenser | 1d | 2019-11-25 | 2019-11-25 |  | 8d |  | start no earlier than 2019-11-25 |
| 16 | 2 | **Inside Cryostat LAr Filter** | 28d | 2019-10-29 | 2019-12-05 |  | 0d |  |  |
| 17 | 2.1 | **Heater Upgrade** | 20d | 2019-10-29 | 2019-11-25 |  | 8d |  |  |
| 18 | 2.1.1 | Purchase Heater assembly | 10d | 2019-10-29 | 2019-11-11 |  | 18d |  | finish no earlier than 2019-11-11 |
| 19 | 2.1.2 | Document heater power supply (Networked, can we use the existing heater power supply) | 1d | 2019-11-13 | 2019-11-13 |  | 16d |  | start no earlier than 2019-11-13 |
| 20 | 2.1.3 | Purchase new RTD for heater | 5d | 2019-11-13 | 2019-11-19 |  | 12d |  | start no earlier than 2019-11-13 |
| 21 | 2.1.4 | Document new heater assembly with power supply (DUNE E&GR) | 3d | 2019-11-13 | 2019-11-15 |  | 14d |  | start no earlier than 2019-11-13 |
| 22 | 2.1.5 | Test heater assembly with RTD and power supply on bench | 5d | 2019-11-13 | 2019-11-19 |  | 12d |  | start no earlier than 2019-11-13 |
| 23 | 2.1.6 | Purchase Straight Pipe for the heater tape insert | 2d | 2019-11-07 | 2019-11-08 |  | 19d |  |  |
| 24 | 2.1.7 | Cut and weld a straight pipe for the heater assembly (Machine Shop) | 2d | 2019-11-22 | 2019-11-25 |  | 8d |  | finish no earlier than 2019-11-25 |
| 26 | 2.2 | **Change of the Sintered Metal Disk** | 17d | 2019-11-04 | 2019-11-26 |  | 7d |  |  |
| 27 | 2.2.1 | Purchase Sintered Metal Disk | 15d | 2019-11-04 | 2019-11-22 |  | 9d |  | start no earlier than 2019-11-04 |
| 28 | 2.2.2 | Purchase new RTD for the inside of the filter | 2d | 2019-11-13 | 2019-11-14 |  | 15d |  | start no earlier than 2019-11-13 |
| 29 | 2.2.3 | HA for emptying and refilling the medial in the filter | 3d | 2019-11-13 | 2019-11-15 |  | 14d |  | start no earlier than 2019-11-13 |
| 30 | 2.2.4 | Empty the media | 2d | 2019-11-20 | 2019-11-21 |  | 6.9d | 0d | start no earlier than 2019-11-20 |
| 31 | 2.2.5 | Install 20 micron Sintered Metal Disk at top and bottom | 2d | 2019-11-22 | 2019-11-25 | 30 | 6.7d | 0d |  |
| 32 | 2.2.6 | Pressure Test the Filter Assembly | 1d | 2019-11-26 | 2019-11-26 | 31 | 6.7d | 0d |  |

| ID | WBS | Task | Duration | Start | Finish | Predecessors | Total slack | Free slack | Constraint |
| --- | --- | --- | --- | --- | --- | --- | --- | --- | --- |
| 34 | 2.3 | **Regeneration of the Filter** | 11.3d | 2019-11-12 | 2019-11-27 |  | 6.7d |  |  |
| 35 | 2.3.1 | Fill media in the filter | 0.1d | 2019-11-27 | 2019-11-27 | 32 | 6.7d | 0d | start no earlier than 2019-11-26 |
| 36 | 2.3.2 | HA for regerating the filter at MicroBooNE | 1d | 2019-11-22 | 2019-11-22 |  | 9d |  | start no earlier than 2019-11-22 |
| 37 | 2.3.3 | Removing the Iceberg internal filter from PAB (crane usage) | 1d | 2019-11-12 | 2019-11-12 |  | 17d |  | start no earlier than 2019-11-12 |
| 38 | 2.3.4 | **the Iceberg internal filter using the MicroBooNe gas recirculation system** | 10.3d | 2019-11-13 | 2019-11-27 |  | 6.7d |  |  |
| 39 | 2.3.4.1 | Fabricating two spool pieces that will connect the inlet and outlet of the Iceberg internal filter to the existing MicroBooNe regen set up | 3d | 2019-11-13 | 2019-11-15 |  | 14d |  | finish no earlier than 2019-11-15 |
| 40 | 2.3.4.2 | Making an adapter to connect the Iceberg RTDs to the existing RTD wiring (going to the MicroBooNe PLC) | 3d | 2019-11-13 | 2019-11-15 |  | 14d |  | start no earlier than 2019-11-13 |
| 41 | 2.3.4.3 | Transporting the Iceberg internal filter to MicroBooNe | 0.1d | 2019-11-27 | 2019-11-27 | 35 | 6.7d | 0d |  |
| 42 | 2.3.4.4 | Lowering the Iceberg internal filter into the MicroBooNe pit (crane usage) | 0.1d | 2019-11-27 | 2019-11-27 | 41 | 6.7d |  |  |
| 43 | 2.3.4.5 | Connecting the Iceberg internal filter RTDs, inlet spool piece, and outlet spool piece | 0.1d | 2019-11-27 | 2019-11-27 | 41 | 6.7d |  |  |
| 44 | 2.4 | Regeneration of the Filter at MicroBooNe | 4d | 2019-11-27 | 2019-12-02 |  | 0d |  | start no earlier than 2019-11-27 |
| 45 | 2.5 | Transporting the Iceberg internal filter to PAB | 1d | 2019-12-03 | 2019-12-03 | 44 | 2d |  |  |
| 46 | 2.6 | Installation of the Filter on Top Plate | 1d | 2019-12-03 | 2019-12-03 | 44 | 0d |  |  |
| 47 | 2.7 | Test the whole assembly with the heater installed for DUNE E&GR | 2d | 2019-12-04 | 2019-12-05 | 46 | 0d |  |  |
| 49 | 2.8 | **Cryostat** | 14d | 2019-11-04 | 2019-11-21 |  | 10d |  |  |
| 50 | 2.8.1 | Purchase new RTD for the cryostat | 9d | 2019-11-04 | 2019-11-14 |  | 15d |  | start no earlier than 2019-11-04 |
| 51 | 2.8.2 | Documentation of RTD assembly | 3d | 2019-11-13 | 2019-11-15 |  | 10d | 0d | start no earlier than 2019-11-13 |
| 52 | 2.8.3 | Assmbly, testing and calibration of RTD | 3d | 2019-11-18 | 2019-11-20 | 51 | 10d | 0d |  |
| 53 | 2.8.4 | Install all the new RTDs | 1d | 2019-11-21 | 2019-11-21 | 52 | 10d |  |  |
| 55 | 2.9 | **Database** | 15d | 2019-11-04 | 2019-11-22 |  | 9d |  |  |
| 56 | 2.9.1 | Inventory all the power and signal cable in and out of ICEBERG | 10d | 2019-11-04 | 2019-11-15 |  | 9d | 0d | start no earlier than 2019-11-04 |
| 57 | 2.9.2 | Make a database entry in the EPICS for all P&S cables | 5d | 2019-11-18 | 2019-11-22 | 56 | 9d |  | start no earlier than 2019-11-18 |
